# Cronograma Imac

Schedule from MS Project, 2008-03-17 to 2008-06-24.
GAE Industrial A. en P.

## Calendars

- Standard: Mon-Fri 08:00-12:00, 13:00-17:00; Sat-Sun off.

## Schedule

| ID | Task | Type | Duration | Start | Finish | Predecessors | Total slack | Free slack | Constraint | Deadline |
| --- | --- | --- | --- | --- | --- | --- | --- | --- | --- | --- |
| 1 | Recepcion de Orden de compra | milestone | 0.1d | 2008-03-17 | 2008-03-17 |  | 0d |  | start no earlier than 2008-03-17 |  |
| 2 | Elaborar lista de materiales consola puente de mando |  | 1d | 2008-03-17 | 2008-03-18 | 1 | 6.9d | 0d |  |  |
| 3 | Elaborar lista de materiales consola cuarto de control |  | 1d | 2008-03-17 | 2008-03-18 | 1 | 70d |  |  |  |
| 4 | Elaborar lista de materiales tablero KA1 |  | 1d | 2008-03-18 | 2008-03-19 | 2 | 6.9d | 0d |  |  |
| 5 | Elaborar lista de materiales tablero KA2 |  | 1d | 2008-03-18 | 2008-03-19 | 2 | 6.9d | 0d |  |  |
| 6 | Elaborar lista de materiales tablero KA3 |  | 1d | 2008-03-18 | 2008-03-19 | 2 | 6.9d | 0d |  |  |
| 7 | Eleborar lista de materiales tablero KA4 |  | 1d | 2008-03-18 | 2008-03-19 | 2 | 6.9d | 0d |  |  |
| 8 | Elaboracion de lista de materiales a proveer por Siemens |  | 1d | 2008-03-19 | 2008-03-20 | 4, 5, 6, 7 | 6.9d | 5.9d |  |  |
| 9 | Elaboracion de Lista de materiales consumibles a proveer por H3 |  | 1d | 2008-03-19 | 2008-03-20 | 4, 5, 6, 7 | 58d | 0d |  |  |
| 10 | Desmontage de Componentes actuales |  | 3d | 2008-03-17 | 2008-03-20 | 1 | 66d | 0d |  |  |
| 11 | Elaboracion de lista de materiales desmontados en buen estado |  | 1d | 2008-03-20 | 2008-03-21 | 10 | 67d |  |  |  |
| 12 | Elaboracion de lista de materiales obsoletos |  | 1d | 2008-03-20 | 2008-03-21 | 10 | 66d | 0d |  |  |
| 13 | Entrega de materiales obsoletos a cliente |  | 1d | 2008-03-21 | 2008-03-24 | 12 | 66d |  |  |  |
| 14 | Desarrollo de planos electricos consola puente de mando |  | 5d | 2008-03-20 | 2008-03-27 | 9 | 63d |  |  |  |
| 15 | Desarrollo de planos electricos consola cuarto de control |  | 5d | 2008-03-20 | 2008-03-27 | 9 | 58d | 0d |  |  |
| 16 | Desarrollo de planos electricos tablero KA1 |  | 5d | 2008-03-27 | 2008-04-03 | 15 | 58d |  |  |  |
| 17 | Desarrollo de Planos electricos tablero KA2 |  | 5d | 2008-03-27 | 2008-04-03 | 15 | 58d |  |  |  |
| 18 | Desarrollo de planos electricos tablero KA3 |  | 5d | 2008-03-27 | 2008-04-03 | 15 | 58d |  |  |  |
| 19 | Desarrollo de Planos electricos tablero KA4 |  | 5d | 2008-03-27 | 2008-04-03 | 15 | 58d |  |  |  |
| 20 | Compra de materiales comsumibles por H3 |  | 1d | 2008-03-17 | 2008-03-18 | 1 | 70d |  |  |  |
| 21 | Recepcion de materiales Por parte de Siemens |  | 1d | 2008-03-28 | 2008-03-28 | 8 | 1d | 0d | start no earlier than 2008-03-28 | 2008-03-31 |
| 22 | Recepcion de Materiales Consumibles H3 |  | 1d | 2008-03-28 | 2008-03-28 |  | 1d | 0d | start no earlier than 2008-03-28 | 2008-03-31 |
| 23 | Fabricacion de Consola Puente de Mando |  | 25d | 2008-03-31 | 2008-05-02 | 21, 22 | 5.1d |  |  |  |
| 24 | Fabricacion de Consola Cuarto de Control |  | 25d | 2008-03-31 | 2008-05-02 | 21, 22 | 5.1d |  |  |  |
| 25 | Fabricacion de Tablero KA1 |  | 25d | 2008-03-31 | 2008-05-02 | 21, 22 | 5.1d |  |  |  |
| 26 | Fabricacion de tablero KA2 |  | 25d | 2008-03-31 | 2008-05-02 | 21, 22 | 5.1d |  |  |  |
| 27 | Fabricacion de Tablero KA3 |  | 25d | 2008-03-31 | 2008-05-02 | 21, 22 | 5.1d |  |  |  |
| 28 | Fabricacion de Tablero KA4 |  | 25d | 2008-03-31 | 2008-05-02 | 21, 22 | 5.1d |  |  |  |
| 29 | Elaboracion de MePo List |  | 10d | 2008-03-17 | 2008-03-31 | 1 | 0d |  |  |  |
| 30 | Desarrollo de Arquitectura Imac |  | 3d | 2008-03-17 | 2008-03-20 | 1 | 58d | 0d |  |  |
| 31 | Desarrollo de Pantallas Imac |  | 30d | 2008-03-31 | 2008-05-12 | 29 | 0d |  |  |  |
| 32 | Desarrollo de programa PLC |  | 30d | 2008-03-31 | 2008-05-12 | 29 | 0d |  |  |  |
| 33 | Elaboracion de lista de cableado o cedula de cableado |  | 10d | 2008-03-20 | 2008-04-03 | 30 | 58d |  |  |  |
| 34 | Pruebas FAT |  | 1d | 2008-05-12 | 2008-05-13 | 31, 32, 23, 24, 25, 26, 27, 28 | 0d |  |  |  |
| 35 | Envio de Tableros a cliente final |  | 1d | 2008-05-13 | 2008-05-14 | 34 | 0d |  |  |  |
| 36 | Instalacion de Tablero en Barco sonora |  | 1d | 2008-05-14 | 2008-05-15 | 35 | 0d |  |  |  |
| 37 | Cableado de señales a Consola de cuarto de control |  | 22d | 2008-05-15 | 2008-06-16 | 36 | 6d |  |  |  |
| 38 | Cableado de señales a consola de puente de mando. |  | 22d | 2008-05-15 | 2008-06-16 | 36 | 6d |  |  |  |
| 39 | Cableado de señales a tablero KA1 |  | 22d | 2008-05-15 | 2008-06-16 | 36 | 6d |  |  |  |
| 40 | Cableado de señales a tablero KA 2 |  | 22d | 2008-05-15 | 2008-06-16 | 36 | 6d |  |  |  |
| 41 | Cableado de señales a tablero KA 3 |  | 22d | 2008-05-15 | 2008-06-16 | 36 | 6d |  |  |  |
| 42 | Cableado de señales a tabrero KA 4 |  | 22d | 2008-05-15 | 2008-06-16 | 36 | 0d |  |  |  |
| 43 | Cableado de la red Ethernet systema Imac |  | 1d | 2008-06-16 | 2008-06-17 | 42 | 5d |  |  |  |
| 44 | Cableado Profibus a sistema Imac |  | 1d | 2008-06-16 | 2008-06-17 | 42 | 0d |  |  |  |
| 45 | Puesta en servicio sistema Imac |  | 1d | 2008-06-17 | 2008-06-18 | 44 | 0d |  |  |  |
| 46 | Prubas de comunicacion con los sistemas MEC71, PMA y CAT3600 |  | 1d | 2008-06-18 | 2008-06-19 | 45 | 0d |  |  |  |
| 47 | Pruebas OSAT |  | 1d | 2008-06-19 | 2008-06-20 | 46 | 0d |  |  |  |
| 48 | Pruebas de Mar |  | 1d | 2008-06-20 | 2008-06-23 | 47 | 0d |  |  |  |
| 49 | Elaboracion de Documentacion |  | 60d | 2008-03-17 | 2008-06-09 | 1 | 11d |  |  |  |
| 50 | Curso de operacion a Tripulacion Barco Sonora |  | 1d | 2008-06-20 | 2008-06-23 | 47 | 0d |  |  |  |
| 51 | Entrega de sistema |  | 1d | 2008-06-23 | 2008-06-24 | 48, 50 | 0d |  |  |  |
